# OB-02 - gewap. fund. balken

Schedule from MS Project, 2003-01-12 to 2003-01-31, status date 2003-01-08.
BAM Nelissen Van Egteren

## Calendars

- ALLEEN WERKDAGEN: Mon-Fri 08:30-12:30, 13:00-17:00; Sat-Sun off. Exceptions (off unless hours are given): 2003-01-11 to 2003-01-12 08:30-12:30, 13:00-17:00, 2003-01-18 to 2003-01-19 08:30-12:30, 13:00-17:00, 2003-01-25 to 2003-01-26 08:30-12:30, 13:00-17:00.

## Schedule

| ID | WBS | Task | Type | Duration | Start | Finish | Predecessors | Total slack |
| --- | --- | --- | --- | --- | --- | --- | --- | --- |
| 1 | 1 | **ONDERBOUWFASE** |  | 20d | 2003-01-12 | 2003-01-31 |  | 0d |
| 2 | 1.1 | werkvloer randkist+beton |  | 2d | 2003-01-12 | 2003-01-13 |  | 0d |
| 3 | 1.2 | balkwapening vlechten |  | 2d | 2003-01-14 | 2003-01-15 | 2SS+2d | 0d |
| 4 | 1.3 | balkbekisting stellen |  | 2d | 2003-01-16 | 2003-01-17 | 3SS+2d | 0d |
| 5 | 1.4 | funderingsbalken storten |  | 2d | 2003-01-18 | 2003-01-19 | 4SS+2d | 0d |
| 6 | 1.5 | funderingsbalken ontkisten |  | 2d | 2003-01-20 | 2003-01-21 | 5SS+2d | 0d |
| 7 | 1.6 | leidingen onder vloer monteren |  | 4d | 2003-01-22 | 2003-01-25 | 6SS+2d | 0d |
| 8 | 1.7 | systeemvloer leggen |  | 2d | 2003-01-26 | 2003-01-27 | 7SS+4d | 0d |
| 9 | 1.8 | randkist+sparingkist vloer |  | 2d | 2003-01-28 | 2003-01-29 | 8SS+2d | 0d |
| 10 | 1.9 | systeemvloer afstorten |  | 1d | 2003-01-30 | 2003-01-30 | 9SS+2d | 0d |
| 11 | 1.10 | maatvoeren voor bovenbouw |  | 1d | 2003-01-31 | 2003-01-31 | 10SS+1d | 0d |
| 12 | 1.11 | start bovenbouw | milestone | 0d | 2003-01-31 | 2003-01-31 | 11SS+1d | 0d |
